# Incremento del servicio al cliente

Schedule from MS Project, 2015-11-03 to 2016-02-05.

## Calendars

- Estándar: Mon-Fri 09:00-13:00, 15:00-19:00; Sat-Sun off.

## Resources

| Resource |
| --- |
| Equipo de servicio al cliente |
| Responsable de servicio al cliente |
| Responsable de tecnología |
| Desarrollador de contenido |
| Formador |
| Logística |

## Schedule

| ID | WBS | Task | Type | Duration | Start | Finish | Predecessors | Total slack | Resources | Work |
| --- | --- | --- | --- | --- | --- | --- | --- | --- | --- | --- |
| 1 | 1 | **Evaluación inicial** |  | 5d? | 2015-11-03 | 2015-11-09 |  | 0d |  | 40h |
| 2 | 1.1 | **Realizar revisión de producto** |  | 5d? | 2015-11-03 | 2015-11-09 |  | 0d |  | 40h |
| 3 | 1.1.1 | Identificar escenarios de uso típicos del producto |  | 1d? | 2015-11-03 | 2015-11-03 |  | 0d | Equipo de servicio al cliente | 8h |
| 4 | 1.1.2 | Identificar tipos de clientes típicos |  | 1d? | 2015-11-04 | 2015-11-04 | 3 | 0d | Equipo de servicio al cliente | 8h |
| 5 | 1.1.3 | Identificar puntos problemáticos de productos de forma anticipada |  | 1d? | 2015-11-05 | 2015-11-05 | 4 | 0d | Equipo de servicio al cliente | 8h |
| 6 | 1.1.4 | Determinar soluciones para puntos de productos |  | 1d? | 2015-11-06 | 2015-11-06 | 5 | 0d | Equipo de servicio al cliente | 8h |
| 7 | 1.1.5 | Documento de resultados de revisión del producto |  | 1d? | 2015-11-09 | 2015-11-09 | 6 | 0d | Equipo de servicio al cliente | 8h |
| 8 | 1.1.6 | Revisión del producto COMPLETADA | milestone | 0d | 2015-11-09 | 2015-11-09 | 7 | 0d |  |  |
| 9 | 2 | **Planeación de servicio** |  | 5d? | 2015-11-10 | 2015-11-16 |  | 0d |  | 48h |
| 10 | 2.1 | **Diseñar servicios de soporte** |  | 4d? | 2015-11-10 | 2015-11-13 |  | 0d |  | 48h |
| 11 | 2.1.1 | **Diseñar escenarios de contacto de servicios de cliente** |  | 1d? | 2015-11-10 | 2015-11-10 |  | 0d |  | 24h |
| 12 | 2.1.1.1 | Soporte en línea |  | 1d? | 2015-11-10 | 2015-11-10 | 8 | 0d | Equipo de servicio al cliente | 8h |
| 13 | 2.1.1.2 | Soporte telefónico |  | 1d? | 2015-11-10 | 2015-11-10 | 8 | 0d | Equipo de servicio al cliente | 8h |
| 14 | 2.1.1.3 | Soporte in situ |  | 1d? | 2015-11-10 | 2015-11-10 | 8 | 0d | Equipo de servicio al cliente | 8h |
| 15 | 2.1.1.4 | Diseño de escenarios de contacto de servicio de atención al cliente COMPLETADO | milestone | 0d | 2015-11-10 | 2015-11-10 | 14, 12, 13 | 0d |  |  |
| 16 | 2.1.2 | **Desarrollar niveles de servicio de atención al cliente (gratis y pagado)** |  | 3d? | 2015-11-11 | 2015-11-13 |  | 0d |  | 24h |
| 17 | 2.1.2.1 | Identificar tipos de problemas para resolver |  | 1d? | 2015-11-11 | 2015-11-11 | 15 | 0d | Equipo de servicio al cliente | 8h |
| 18 | 2.1.2.2 | Identificar opciones de entrega de servicio |  | 1d? | 2015-11-12 | 2015-11-12 | 17 | 0d | Equipo de servicio al cliente | 8h |
| 19 | 2.1.2.3 | Determinar conocimientos necesarios para las diferentes opciones de soporte |  | 1d? | 2015-11-13 | 2015-11-13 | 18 | 0d | Equipo de servicio al cliente | 8h |
| 20 | 2.1.2.4 | Diseño de nivel de servicio del cliente COMPLETADO | milestone | 0d | 2015-11-13 | 2015-11-13 | 19 | 0d |  |  |
| 21 | 2.1.3 | Diseño de servicios de soporte COMPLETADO | milestone | 0d | 2015-11-13 | 2015-11-13 | 20 | 0d |  |  |
| 22 | 2.2 | Planeación y diseño de servicio COMPLETADO |  | 1d? | 2015-11-16 | 2015-11-16 | 21 | 0d |  |  |
| 23 | 3 | **Planeación de infraestructura de entrega de servicio** |  | 34.5d? | 2015-11-10 | 2015-12-28 |  | 5d |  | 256h |
| 24 | 3.1 | **Requisitos de recursos** |  | 3d? | 2015-11-17 | 2015-11-19 |  | 0d |  | 24h |
| 25 | 3.1.1 | Demanda estimada de soporte al cliente (todas las opciones) |  | 1d? | 2015-11-17 | 2015-11-17 | 22 | 0d | Responsable de servicio al cliente | 8h |
| 26 | 3.1.2 | Estimar requisitos de recursos |  | 1d? | 2015-11-18 | 2015-11-18 | 25 | 0d | Responsable de servicio al cliente | 8h |
| 27 | 3.1.3 | Estimar esfuerzo para contratar nuevos recursos |  | 1d? | 2015-11-19 | 2015-11-19 | 26 | 0d | Responsable de servicio al cliente | 8h |
| 28 | 3.1.4 | Planeación de recursos COMPLETADA | milestone | 0d | 2015-11-19 | 2015-11-19 | 27 | 0d |  |  |

| ID | WBS | Task | Type | Duration | Start | Finish | Predecessors | Total slack | Resources | Work |
| --- | --- | --- | --- | --- | --- | --- | --- | --- | --- | --- |
| 29 | 3.2 | **Formación y disponibilidad** |  | 34.5d? | 2015-11-10 | 2015-12-28 |  | 0d |  | 216h |
| 30 | 3.2.1 | **Valoración de necesidades de formación** |  | 9.5d? | 2015-11-10 | 2015-11-23 |  | 0d |  | 24h |
| 31 | 3.2.1.1 | Revise los resultados de la fase de revisión del producto |  | 1d? | 2015-11-10 | 2015-11-10 | 8 | 8d | Desarrollador de contenido | 8h |
| 32 | 3.2.1.2 | Revisar los conjuntos de aptitudes de los recursos de apoyo |  | 1d? | 2015-11-20 | 2015-11-20 | 28 | 0d | Desarrollador de contenido | 8h |
| 33 | 3.2.1.3 | Determinar necesidades de formación específicas del producto |  | 0.5d? | 2015-11-23 | 2015-11-23 | 32, 31 | 0d | Responsable de servicio al cliente; Desarrollador de contenido | 8h |
| 34 | 3.2.1.4 | Valoración de necesidades de formación COMPLETADA | milestone | 0d | 2015-11-23 | 2015-11-23 | 33 | 0d |  |  |
| 35 | 3.2.2 | **Planeación de formación** |  | 25d? | 2015-11-23 | 2015-12-28 |  | 0d |  | 192h |
| 36 | 3.2.2.1 | **Planeación de desarrollo de contenido** |  | 8d? | 2015-11-23 | 2015-12-03 |  | 0d |  | 64h |
| 37 | 3.2.2.1.1 | Determinar métodos para ofrecer formación |  | 1d? | 2015-11-23 | 2015-11-24 | 34 | 0d | Desarrollador de contenido | 8h |
| 38 | 3.2.2.1.2 | Determinar el factor de forma para el contenido de la formación |  | 1d? | 2015-11-24 | 2015-11-25 | 37 | 0d | Desarrollador de contenido | 8h |
| 39 | 3.2.2.1.3 | Identificar recursos internos que pueden revisar materiales de formación |  | 1d? | 2015-11-25 | 2015-11-26 | 38 | 0d | Responsable de servicio al cliente | 8h |
| 40 | 3.2.2.1.4 | Determinar temas de los cursos de formación |  | 1d? | 2015-11-26 | 2015-11-27 | 39 | 0d | Desarrollador de contenido | 8h |
| 41 | 3.2.2.1.5 | Determinar el número de cursos de formación |  | 1d? | 2015-11-27 | 2015-11-30 | 40 | 0d | Desarrollador de contenido | 8h |
| 42 | 3.2.2.1.6 | Diseñar materiales para el estudiante |  | 1d? | 2015-11-30 | 2015-12-01 | 41 | 0d | Desarrollador de contenido | 8h |
| 43 | 3.2.2.1.7 | Borrador de la descripción de los programas o cursos de formación |  | 1d? | 2015-12-01 | 2015-12-02 | 42 | 0d | Desarrollador de contenido | 8h |
| 44 | 3.2.2.1.8 | Borrador del presupuesto de desarrollo de contenido |  | 1d? | 2015-12-02 | 2015-12-03 | 43 | 0d | Desarrollador de contenido | 8h |
| 45 | 3.2.2.1.9 | Planeación de desarrollo de contenido COMPLETADO | milestone | 0d | 2015-12-03 | 2015-12-03 | 44 | 0d |  |  |
| 46 | 3.2.2.2 | **Planeación de implementación de formación** |  | 14d? | 2015-12-03 | 2015-12-23 |  | 0d |  | 104h |
| 47 | 3.2.2.2.1 | **Evaluar las necesidades y opciones del formador** |  | 8d? | 2015-12-03 | 2015-12-15 |  | 0d |  | 64h |
| 48 | 3.2.2.2.1.1 | Identificar recursos internos que puedan servir como formadores potenciales |  | 1d? | 2015-12-03 | 2015-12-04 | 45 | 0d | Responsable de servicio al cliente | 8h |
| 49 | 3.2.2.2.1.2 | Determinar si se necesitarán formadores adicionales |  | 1d? | 2015-12-04 | 2015-12-07 | 48 | 0d | Responsable de servicio al cliente | 8h |
| 50 | 3.2.2.2.1.3 | **Revisar opciones de subcontratación: implementación de formación** |  | 6d? | 2015-12-07 | 2015-12-15 |  | 0d |  | 48h |
| 51 | 3.2.2.2.1.3.1 | Revisar conocimientos de los proveedores potenciales |  | 1d? | 2015-12-07 | 2015-12-08 | 49 | 0d | Responsable de servicio al cliente | 8h |
| 52 | 3.2.2.2.1.3.2 | Revisar coste |  | 1d? | 2015-12-08 | 2015-12-09 | 51 | 0d | Responsable de servicio al cliente | 8h |
| 53 | 3.2.2.2.1.3.3 | Revisar niveles de servicio |  | 1d? | 2015-12-09 | 2015-12-10 | 52 | 0d | Responsable de servicio al cliente | 8h |
| 54 | 3.2.2.2.1.3.4 | Revisar referencias del cliente |  | 1d? | 2015-12-10 | 2015-12-11 | 53 | 0d | Responsable de servicio al cliente | 8h |
| 55 | 3.2.2.2.1.3.5 | Determinar el tiempo necesario para preparar a los formadores externos |  | 1d? | 2015-12-11 | 2015-12-14 | 54 | 0d | Responsable de servicio al cliente | 8h |
| 56 | 3.2.2.2.1.3.6 | Tomar la decisión de subcontratación |  | 1d? | 2015-12-14 | 2015-12-15 | 55 | 0d | Responsable de servicio al cliente | 8h |
| 57 | 3.2.2.2.1.3.7 | Revisión de subcontratación COMPLETADA | milestone | 0d | 2015-12-15 | 2015-12-15 | 56 | 0d |  |  |
| 58 | 3.2.2.2.1.4 | Valoración de necesidades del formador COMPLETADA | milestone | 0d | 2015-12-15 | 2015-12-15 | 57 | 0d |  |  |

| ID | WBS | Task | Type | Duration | Start | Finish | Predecessors | Total slack | Free slack | Resources | Work |
| --- | --- | --- | --- | --- | --- | --- | --- | --- | --- | --- | --- |
| 59 | 3.2.2.2.2 | **Logística de implementación de la formación** |  | 5d? | 2015-12-15 | 2015-12-22 |  | 0d |  |  | 32h |
| 60 | 3.2.2.2.2.1 | Crear programación de implementación de formación |  | 1d? | 2015-12-15 | 2015-12-16 | 58 | 0d |  | Responsable de servicio al cliente | 8h |
| 61 | 3.2.2.2.2.2 | Determinar ubicaciones de implementación de la formación |  | 1d? | 2015-12-16 | 2015-12-17 | 60 | 0d |  | Responsable de servicio al cliente | 8h |
| 62 | 3.2.2.2.2.3 | Revisar opciones de subcontratación: logísticas de evento |  | 1d? | 2015-12-17 | 2015-12-18 | 61 | 0d |  | Responsable de servicio al cliente | 8h |
| 63 | 3.2.2.2.2.4 | Desarrollar presupuesto de formación |  | 1d? | 2015-12-18 | 2015-12-21 | 62 | 0d |  | Responsable de servicio al cliente | 8h |
| 64 | 3.2.2.2.2.5 | Logística de implementación de formación COMPLETADA |  | 1d? | 2015-12-21 | 2015-12-22 | 63 | 0d |  |  |  |
| 65 | 3.2.2.2.3 | Crear plan de formación con los resultados de las fases de desarrollo de contenido e implementación de la formación |  | 1d? | 2015-12-22 | 2015-12-23 | 64 | 0d |  | Responsable de servicio al cliente | 8h |
| 66 | 3.2.2.2.4 | Planeación de implementación de formación completada | milestone | 0d | 2015-12-23 | 2015-12-23 | 65 | 0d |  |  |  |
| 67 | 3.2.2.3 | **Finalizar planeación de formación** |  | 3d? | 2015-12-23 | 2015-12-28 |  | 0d |  |  | 24h |
| 68 | 3.2.2.3.1 | Borrador del presupuesto general |  | 1d? | 2015-12-23 | 2015-12-24 | 66 | 0d |  | Responsable de servicio al cliente | 8h |
| 69 | 3.2.2.3.2 | Obtener la aprobación ejecutiva sobre el presupuesto |  | 1d? | 2015-12-24 | 2015-12-25 | 68 | 0d |  | Responsable de servicio al cliente | 8h |
| 70 | 3.2.2.3.3 | Obtener la aprobación ejecutiva sobre los planes de formación |  | 1d? | 2015-12-25 | 2015-12-28 | 69 | 0d |  | Responsable de servicio al cliente | 8h |
| 71 | 3.2.2.4 | Planeación de formación COMPLETADA | milestone | 0d | 2015-12-28 | 2015-12-28 | 70 | 0d |  |  |  |
| 72 | 3.3 | **Infraestructura de tecnología** |  | 2d? | 2015-11-17 | 2015-11-18 |  | 43.5d |  |  | 16h |
| 73 | 3.3.1 | Crear plan de infraestructura tecnológica (se requiere un plan de proyecto separado) |  | 1d? | 2015-11-17 | 2015-11-17 | 22 | 43.5d | 0d | Responsable de tecnología | 8h |
| 74 | 3.3.2 | Determinar presupuesto de tecnología |  | 1d? | 2015-11-18 | 2015-11-18 | 73 | 43.5d | 0d | Responsable de tecnología | 8h |
| 75 | 3.3.3 | Planeación de infraestructura tecnológica COMPLETADA | milestone | 0d | 2015-11-18 | 2015-11-18 | 74 | 43.5d | 0d |  |  |
| 76 | 3.4 | Planeamiento de implementación de servicio COMPLETADA | milestone | 0d | 2015-11-18 | 2015-11-18 | 75 | 56.5d |  |  |  |
| 77 | 4 | **Planeación de rendimiento comercial** |  | 3d? | 2015-11-16 | 2015-11-18 |  | 51.5d |  |  | 24h |
| 78 | 4.1 | Determinar objetivos empresariales de servicios de soporte |  | 1d? | 2015-11-16 | 2015-11-16 | 21 | 51.5d | 0d | Responsable de servicio al cliente | 8h |
| 79 | 4.2 | Determinar métrica del éxito |  | 1d? | 2015-11-17 | 2015-11-17 | 78 | 51.5d | 0d | Equipo de servicio al cliente | 8h |
| 80 | 4.3 | Determinar estándares de eficacia de coste |  | 1d? | 2015-11-18 | 2015-11-18 | 79 | 51.5d | 0d | Equipo de servicio al cliente | 8h |
| 81 | 4.4 | Se completo la planeación de rendimiento comercial | milestone | 0d | 2015-11-18 | 2015-11-18 | 80 | 51.5d | 0d |  |  |
| 82 | 5 | **Crear programas de servicios de cliente** |  | 43.5d? | 2015-11-19 | 2016-01-19 |  | 13d |  |  | 188h |
| 83 | 5.1 | **Desarrollo de formación o disponibilidad** |  | 16d? | 2015-12-28 | 2016-01-19 |  | 0d |  |  | 128h |
| 84 | 5.1.1 | **Desarrollo de contenido de formación** |  | 9d? | 2015-12-28 | 2016-01-08 |  | 0d |  |  | 72h |
| 85 | 5.1.1.1 | Constituir equipo de desarrollo de contenido |  | 1d? | 2015-12-28 | 2015-12-29 | 71 | 0d |  | Responsable de servicio al cliente | 8h |
| 86 | 5.1.1.2 | Definir funciones y responsabilidades |  | 1d? | 2015-12-29 | 2015-12-30 | 85 | 0d |  | Responsable de servicio al cliente | 8h |
| 87 | 5.1.1.3 | Crear programación de desarrollo de contenido |  | 1d? | 2015-12-30 | 2015-12-31 | 86 | 0d |  | Responsable de servicio al cliente | 8h |

| ID | WBS | Task | Type | Duration | Start | Finish | Predecessors | Total slack | Free slack | Resources | Work |
| --- | --- | --- | --- | --- | --- | --- | --- | --- | --- | --- | --- |
| 88 | 5.1.1.4 | **Crear contenido de formación** |  | 6d? | 2015-12-31 | 2016-01-08 |  | 0d |  |  | 48h |
| 89 | 5.1.1.4.1 | Revisar propiedad intelectual existente |  | 1d? | 2015-12-31 | 2016-01-01 | 87 | 0d |  | Desarrollador de contenido | 8h |
| 90 | 5.1.1.4.2 | Desarrollar contenido beta |  | 1d? | 2016-01-01 | 2016-01-04 | 89 | 0d |  | Desarrollador de contenido | 8h |
| 91 | 5.1.1.4.3 | Efectuar la revisión de SME del contenido de formación |  | 1d? | 2016-01-04 | 2016-01-05 | 90 | 0d |  | Desarrollador de contenido | 8h |
| 92 | 5.1.1.4.4 | Revisar y actualizar contenido |  | 1d? | 2016-01-05 | 2016-01-06 | 91 | 0d |  | Desarrollador de contenido | 8h |
| 93 | 5.1.1.4.5 | Crear "hojas de referencia rápida" y recursos de aprendizaje adicionales de apoyo al cliente |  | 1d? | 2016-01-06 | 2016-01-07 | 92 | 0d |  | Desarrollador de contenido | 8h |
| 94 | 5.1.1.4.6 | Obtener aprobación de contenido final |  | 1d? | 2016-01-07 | 2016-01-08 | 93 | 0d |  | Responsable de servicio al cliente | 8h |
| 95 | 5.1.1.5 | Desarrollo de contenido COMPLETADO | milestone | 0d | 2016-01-08 | 2016-01-08 | 94 | 0d |  |  |  |
| 96 | 5.1.2 | **Desarrollar motor de formación** |  | 7d? | 2016-01-08 | 2016-01-19 |  | 0d |  |  | 56h |
| 97 | 5.1.2.1 | Crear materiales de formación adicionales para "formar al formador" |  | 1d? | 2016-01-08 | 2016-01-11 | 95 | 0d |  | Desarrollador de contenido | 8h |
| 98 | 5.1.2.2 | Crear exámenes de competencias |  | 1d? | 2016-01-11 | 2016-01-12 | 97 | 0d |  | Desarrollador de contenido | 8h |
| 99 | 5.1.2.3 | Formar a formadores adicionales |  | 1d? | 2016-01-12 | 2016-01-13 | 98 | 0d |  | Formador | 8h |
| 100 | 5.1.2.4 | Preparar lugares de formación |  | 1d? | 2016-01-13 | 2016-01-14 | 99 | 0d |  | Logística | 8h |
| 101 | 5.1.2.5 | Crear plan de comunicaciones |  | 1d? | 2016-01-14 | 2016-01-15 | 100 | 0d |  | Responsable de servicio al cliente | 8h |
| 102 | 5.1.2.6 | Proporcionar a los nuevos contratados información sobre el programa de formación |  | 1d? | 2016-01-15 | 2016-01-18 | 101 | 0d |  | Responsable de servicio al cliente | 8h |
| 103 | 5.1.2.7 | Enviar comunicación referente al nuevo plan de formación a los recursos de soporte existentes |  | 1d? | 2016-01-18 | 2016-01-19 | 102 | 0d |  | Responsable de servicio al cliente | 8h |
| 104 | 5.1.2.8 | Desarrollo del motor de formación COMPLETADO | milestone | 0d | 2016-01-19 | 2016-01-19 | 103 | 0d |  |  |  |
| 105 | 5.1.3 | Implementación de disponibilidad y formación COMPLETADA | milestone | 0d | 2016-01-19 | 2016-01-19 | 104 | 13d |  |  |  |
| 106 | 5.2 | **Crear infraestructura tecnológica** |  | 2d? | 2015-11-19 | 2015-11-20 |  | 43.5d |  |  | 20h |
| 107 | 5.2.1 | Diseñar y desarrollar soluciones tecnológicas (es necesaria una programación por separado) |  | 1d? | 2015-11-19 | 2015-11-19 | 75 | 43.5d | 0d | Responsable de tecnología | 8h |
| 108 | 5.2.2 | Probar la infraestructura tecnológica |  | 1d? | 2015-11-20 | 2015-11-20 | 107 | 43.5d | 0d | Equipo de servicio al cliente; Responsable de tecnología; Desarrollador de contenido | 12h |
| 109 | 5.2.3 | Implementación de la infraestructura tecnológica COMPLETADA | milestone | 0d | 2015-11-20 | 2015-11-20 | 108 | 54.5d |  |  |  |
| 110 | 5.3 | **Implementación del programa de servicio al cliente** |  | 5d? | 2015-11-19 | 2015-11-25 |  | 51.5d |  |  | 40h |
| 111 | 5.3.1 | Crear programas de servicios de atención al cliente |  | 1d? | 2015-11-19 | 2015-11-19 | 81 | 51.5d | 0d | Equipo de servicio al cliente | 8h |
| 112 | 5.3.2 | Realizar revisión por expertos en la materia |  | 1d? | 2015-11-20 | 2015-11-20 | 111 | 51.5d | 0d | Equipo de servicio al cliente | 8h |
| 113 | 5.3.3 | Realizar pruebas de aceptación del usuario con los clientes |  | 1d? | 2015-11-23 | 2015-11-23 | 112 | 51.5d | 0d | Equipo de servicio al cliente | 8h |
| 114 | 5.3.4 | Revisar programas y procesos relacionados |  | 1d? | 2015-11-24 | 2015-11-24 | 113 | 51.5d | 0d | Equipo de servicio al cliente | 8h |
| 115 | 5.3.5 | Obtener aprobación ejecutiva |  | 1d? | 2015-11-25 | 2015-11-25 | 114 | 51.5d | 0d | Responsable de servicio al cliente | 8h |
| 116 | 5.3.6 | Desarrollo del programa de servicio al cliente COMPLETADO | milestone | 0d | 2015-11-25 | 2015-11-25 | 115 | 51.5d |  |  |  |

| ID | WBS | Task | Type | Duration | Start | Finish | Predecessors | Total slack | Resources | Work |
| --- | --- | --- | --- | --- | --- | --- | --- | --- | --- | --- |
| 117 | 6 | **Implementación del programa** |  | 45.5d? | 2015-11-23 | 2016-01-25 |  | 9d |  | 40h |
| 118 | 6.1 | **Disponibilidad de recursos** |  | 3d? | 2016-01-19 | 2016-01-22 |  | 0d |  | 24h |
| 119 | 6.1.1 | Contratar nuevos recursos |  | 1d? | 2016-01-19 | 2016-01-20 | 94, 104 | 0d | Responsable de servicio al cliente | 8h |
| 120 | 6.1.2 | Formar nuevos recursos |  | 1d? | 2016-01-20 | 2016-01-21 | 119 | 0d | Formador | 8h |
| 121 | 6.1.3 | Certificar nuevos recursos |  | 1d? | 2016-01-21 | 2016-01-22 | 120 | 0d | Responsable de servicio al cliente | 8h |
| 122 | 6.1.4 | Formación de disponibilidad de recursos COMPLETADA | milestone | 0d | 2016-01-22 | 2016-01-22 | 121 | 10d |  |  |
| 123 | 6.2 | Desarrollar infraestructura de tecnología |  | 1d? | 2015-11-23 | 2015-11-23 | 108 | 43.5d | Responsable de tecnología | 8h |
| 124 | 6.3 | Desarrollar nuevos programas de servicio para el cliente |  | 1d? | 2016-01-22 | 2016-01-25 | 123, 121 | 0d | Responsable de servicio al cliente | 8h |
| 125 | 6.4 | Implementación del programa COMPLETADA | milestone | 0d | 2016-01-25 | 2016-01-25 | 124 | 0d |  |  |
| 126 | 7 | **Después del lanzamiento** |  | 9d? | 2016-01-25 | 2016-02-05 |  | 0d |  | 72h |
| 127 | 7.1 | **Participar en actividades de preparación posteriores al lanzamiento** |  | 9d? | 2016-01-25 | 2016-02-05 |  | 0d |  | 72h |
| 128 | 7.1.1 | Determinar métrica del éxito |  | 1d? | 2016-01-25 | 2016-01-26 | 125 | 0d | Equipo de servicio al cliente | 8h |
| 129 | 7.1.2 | Crear métodos para realizar el seguimiento de los problemas y soluciones comunes |  | 1d? | 2016-01-26 | 2016-01-27 | 128 | 0d | Equipo de servicio al cliente | 8h |
| 130 | 7.1.3 | Crear métodos para el seguimiento de problemas de soporte frente a otros aspectos del producto |  | 1d? | 2016-01-27 | 2016-01-28 | 129 | 0d | Equipo de servicio al cliente | 8h |
| 131 | 7.1.4 | Crear métodos para distribuir soluciones comunes para todos los recursos de soporte |  | 1d? | 2016-01-28 | 2016-01-29 | 130 | 0d | Equipo de servicio al cliente | 8h |
| 132 | 7.1.5 | Preparación posterior al lanzamiento COMPLETADA | milestone | 0d | 2016-01-29 | 2016-01-29 | 131 | 0d |  |  |
| 133 | 7.1.6 | **Seguimiento** |  | 5d? | 2016-01-29 | 2016-02-05 |  | 0d |  | 40h |
| 134 | 7.1.6.1 | Supervisar problemas de soporte al cliente: buscar problemas comunes |  | 1d? | 2016-01-29 | 2016-02-01 | 132 | 0d | Equipo de servicio al cliente | 8h |
| 135 | 7.1.6.2 | Mejores prácticas agregadas (soluciones): distribuir para dar soporte a los servicios |  | 1d? | 2016-02-01 | 2016-02-02 | 134 | 0d | Equipo de servicio al cliente | 8h |
| 136 | 7.1.6.3 | Revisar datos de soporte, determinar qué aspectos del producto provocan más problemas de soporte |  | 1d? | 2016-02-02 | 2016-02-03 | 135 | 0d | Equipo de servicio al cliente | 8h |
| 137 | 7.1.6.4 | Revisar el rendimiento de los recursos |  | 1d? | 2016-02-03 | 2016-02-04 | 136 | 0d | Equipo de servicio al cliente | 8h |
| 138 | 7.1.6.5 | Revisar materiales de formación |  | 1d? | 2016-02-04 | 2016-02-05 | 137 | 0d | Desarrollador de contenido | 8h |
| 139 | 7.2 | Actividades posteriores al lanzamiento COMPLETADAS | milestone | 0d | 2016-02-05 | 2016-02-05 | 138 | 0d |  |  |
| 140 | 8 | Desarrollo del programa de servicio al cliente COMPLETADO | milestone | 0d | 2016-02-05 | 2016-02-05 | 139 | 0d |  |  |
