# Lanzamiento nuevo producto

Schedule from MS Project, 2015-11-21 to 2015-12-18.

## Calendars

- Estándar: Mon-Fri 09:00-13:00, 15:00-19:00; Sat-Sun off.

## Resources

| Resource |
| --- |
| Ingeniería |
| Fabricación |
| Marketing |
| Ventas |
| Soporte técnico |
| Servicio de campo |
| Director de producto |

## Schedule

| ID | WBS | Task | Type | Duration | Start | Finish | Predecessors | Total slack | Resources | Work |
| --- | --- | --- | --- | --- | --- | --- | --- | --- | --- | --- |
| 1 | 1 | Lea la nota para obtener una explicación del objetivo de esta plantilla | milestone | 0d | 2015-11-21 | 2015-11-21 |  | 0d |  |  |
| 2 | 2 | **Preparación de lanzamiento del nuevo producto** |  | 20d? | 2015-11-23 | 2015-12-18 |  | 0d |  | 380h |
| 3 | 2.1 | **Fase 1 - Planeación** |  | 7d? | 2015-11-23 | 2015-12-01 |  | 0d |  | 68h |
| 4 | 2.1.1 | Identificar el equipo de lanzamiento |  | 1d? | 2015-11-23 | 2015-11-23 | 1 | 0d | Ingeniería; Fabricación; Marketing; Ventas; Soporte técnico; Servicio de campo; Director de producto | 12h |
| 5 | 2.1.2 | Determinar los objetivos de ventas |  | 1d? | 2015-11-24 | 2015-11-24 | 4 | 0d | Director de producto | 8h |
| 6 | 2.1.3 | Definir objetivos del lanzamiento (fechas del lanzamiento y objetivos de publicidad) |  | 1d? | 2015-11-25 | 2015-11-25 | 5 | 0d | Director de producto | 8h |
| 7 | 2.1.4 | **Determinar socios (si fuera necesario)** |  | 1d? | 2015-11-26 | 2015-11-26 |  | 0d |  | 24h |
| 8 | 2.1.4.1 | Identificar socios del canal |  | 1d? | 2015-11-26 | 2015-11-26 | 6 | 0d | Marketing | 8h |
| 9 | 2.1.4.2 | Identificar socios de ventas |  | 1d? | 2015-11-26 | 2015-11-26 | 6 | 0d | Marketing | 8h |
| 10 | 2.1.4.3 | Identificar oportunidades en línea |  | 1d? | 2015-11-26 | 2015-11-26 | 6 | 0d | Marketing | 8h |
| 11 | 2.1.5 | **Establecer presupuesto de lanzamiento** |  | 2d? | 2015-11-27 | 2015-11-30 |  | 0d |  | 16h |
| 12 | 2.1.5.1 | Identificar requisitos de presupuesto |  | 1d? | 2015-11-27 | 2015-11-27 | 8, 9, 10 | 0d | Director de producto | 8h |
| 13 | 2.1.5.2 | Obtener aprobación del presupuesto de lanzamiento |  | 1d? | 2015-11-30 | 2015-11-30 | 12 | 0d | Director de producto | 8h |
| 14 | 2.1.6 | Planeación COMPLETADA |  | 1d? | 2015-12-01 | 2015-12-01 | 13 | 0d |  |  |
| 15 | 2.2 | **Fase 2: iniciación** |  | 6d? | 2015-12-02 | 2015-12-09 |  | 0d |  | 116h |
| 16 | 2.2.1 | Puesta en marcha del lanzamiento del producto |  | 1d? | 2015-12-02 | 2015-12-02 | 14 | 0d | Director de producto | 8h |
| 17 | 2.2.2 | **Marketing** |  | 3d? | 2015-12-03 | 2015-12-07 |  | 0d |  | 48h |
| 18 | 2.2.2.1 | Definir el resumen creativo |  | 1d? | 2015-12-03 | 2015-12-03 | 16 | 0d | Director de producto | 8h |
| 19 | 2.2.2.2 | **Preparar marco de trabajo de mensajería** |  | 1d? | 2015-12-04 | 2015-12-04 |  | 0d |  | 40h |
| 20 | 2.2.2.2.1 | Revisar información actual y planear nuevos requisitos |  | 1d? | 2015-12-04 | 2015-12-04 | 18 | 0d | Marketing | 8h |
| 21 | 2.2.2.2.2 | Definir requisitos de comunicados de prensa |  | 1d? | 2015-12-04 | 2015-12-04 | 18 | 0d | Marketing | 8h |
| 22 | 2.2.2.2.3 | Definir información de especificaciones del producto |  | 1d? | 2015-12-04 | 2015-12-04 | 18 | 0d | Marketing | 8h |
| 23 | 2.2.2.2.4 | Definir presentaciones de ventas |  | 1d? | 2015-12-04 | 2015-12-04 | 18 | 0d | Marketing | 8h |
| 24 | 2.2.2.2.5 | Definir necesidades de comunicación internas |  | 1d? | 2015-12-04 | 2015-12-04 | 18 | 0d | Marketing | 8h |
| 25 | 2.2.2.3 | Marco de trabajo de mensajería COMPLETADO |  | 1d? | 2015-12-07 | 2015-12-07 | 20, 21, 22, 23, 24 | 0d |  |  |

Notes:
- 1: Esta plantilla ayudará al usuario a definir y administrar los componentes clave incluidos en un plan de lanzamiento del producto: objetivos de ventas claramente definidos; disponibilidad asegurada del canal de ventas; funciones promocionales (relaciones públicas, marketing y publicidad); y recursos para supervisar y explicar su ejecución. / El lanzamiento de un producto se realiza normalmente bajo la orientación y dirección de la organización de marketing y el administrador del producto para el producto. El resto de departamentos tendrán una función de soporte en el plan y programación de lanzamiento. Por esta razón, la mayoría de actividades de esta plantilla se centrarán en las actividades de marketing. Se necesitarán planes adicionales para el trabajo realizado en otros departamentos para preparar el lanzamiento del producto.
- 16: Esta tarea normalmente se lleva a cabo con una reunión junto con las personas claves. El objetivo de la reunión es compartir los objetivos del lanzamiento del producto y proporcionar a los departamentos suficiente información para crear planes de departamento para el lanzamiento.

| ID | WBS | Task | Type | Duration | Start | Finish | Predecessors | Total slack | Free slack | Resources | Work |
| --- | --- | --- | --- | --- | --- | --- | --- | --- | --- | --- | --- |
| 26 | 2.2.3 | **Ingeniería** |  | 1d? | 2015-12-03 | 2015-12-03 |  | 2d |  |  | 8h |
| 27 | 2.2.3.1 | Coordinar las fechas de lanzamiento del producto con el plan de marketing |  | 1d? | 2015-12-03 | 2015-12-03 | 16 | 2d |  | Ingeniería | 8h |
| 28 | 2.2.4 | **Fabricación** |  | 1d? | 2015-12-03 | 2015-12-03 |  | 2d |  |  | 8h |
| 29 | 2.2.4.1 | Preparar fabricación de acuerdo con los objetivos de ventas |  | 1d? | 2015-12-03 | 2015-12-03 | 16 | 2d |  | Fabricación | 8h |
| 30 | 2.2.5 | **Ventas** |  | 1d? | 2015-12-03 | 2015-12-03 |  | 2d |  |  | 8h |
| 31 | 2.2.5.1 | Planear el personal de la fuerza de ventas y la formación para soportar objetivos de ventas |  | 1d? | 2015-12-03 | 2015-12-03 | 16 | 2d |  | Ventas | 8h |
| 32 | 2.2.6 | **Soporte técnico** |  | 1d? | 2015-12-03 | 2015-12-03 |  | 2d |  |  | 8h |
| 33 | 2.2.6.1 | Planear personal del equipo para apoyar a los objetivos de ventas |  | 1d? | 2015-12-03 | 2015-12-03 | 16 | 2d |  | Soporte técnico | 8h |
| 34 | 2.2.7 | **Servicio de campo** |  | 1d? | 2015-12-03 | 2015-12-03 |  | 2d |  |  | 8h |
| 35 | 2.2.7.1 | Planear el personal del servicio de campo para apoyar a los objetivos de ventas |  | 1d? | 2015-12-03 | 2015-12-03 | 16 | 2d |  | Servicio de campo | 8h |
| 36 | 2.2.8 | Proporcionar requisitos actualizados y presupuestos basados en los planes del departamento |  | 1d? | 2015-12-08 | 2015-12-08 | 35, 33, 31, 29, 27, 25 | 0d |  | Ingeniería; Fabricación; Marketing; Ventas; Soporte técnico; Servicio de campo | 12h |
| 37 | 2.2.9 | Obtener aprobación para planes y presupuestos actualizados. |  | 1d? | 2015-12-09 | 2015-12-09 | 36 | 0d |  | Director de producto | 8h |
| 38 | 2.2.10 | Fase de iniciación COMPLETADA | milestone | 0d | 2015-12-09 | 2015-12-09 | 37 | 0d |  |  |  |
| 39 | 2.3 | **Fase 3: ejecución** |  | 4d? | 2015-12-10 | 2015-12-15 |  | 0d |  |  | 136h |
| 40 | 2.3.1 | **Marketing** |  | 4d? | 2015-12-10 | 2015-12-15 |  | 0d |  |  | 72h |
| 41 | 2.3.1.1 | Evaluar mercado y volver a definir la mensajería |  | 1d? | 2015-12-10 | 2015-12-10 | 38 | 0d |  | Marketing | 8h |
| 42 | 2.3.1.2 | Diseñar y solicitar empaquetado final |  | 1d? | 2015-12-11 | 2015-12-11 | 41 | 0d |  | Marketing | 8h |
| 43 | 2.3.1.3 | Crear comunicados de prensa |  | 1d? | 2015-12-11 | 2015-12-11 | 41 | 0d |  | Marketing | 8h |
| 44 | 2.3.1.4 | Crear información de especificaciones del producto |  | 1d? | 2015-12-11 | 2015-12-11 | 41 | 0d |  | Marketing | 8h |
| 45 | 2.3.1.5 | Crear presentaciones de ventas |  | 1d? | 2015-12-11 | 2015-12-11 | 41 | 0d |  | Marketing | 8h |
| 46 | 2.3.1.6 | Informar de los detalles de lanzamiento del producto a la organización interna |  | 1d? | 2015-12-14 | 2015-12-14 | 41, 42, 43, 44, 45 | 0d |  | Marketing | 8h |
| 47 | 2.3.1.7 | Realizar formación de soporte de ventas, campo y soporte |  | 1d? | 2015-12-15 | 2015-12-15 | 46 | 0d |  | Marketing | 8h |
| 48 | 2.3.1.8 | Actualizar pronósticos del producto según los comentarios y análisis de mercado |  | 1d? | 2015-12-11 | 2015-12-11 | 41 | 1d | 0d | Marketing | 8h |
| 49 | 2.3.1.9 | Actualizar plan de lanzamiento según los pronósticos |  | 1d? | 2015-12-14 | 2015-12-14 | 48 | 1d |  | Marketing | 8h |

Notes:
- 27: El departamento de ingeniería tendrá sus propios planes para completar el desarrollo del producto. Su participación en este plan es para coordinar las fechas del lanzamiento, especificaciones de producto y experiencia en la materia sobre las capacidades y características del producto.
- 29: El departamento de fabricación tendrá sus propios planes para preparar y comercializar el producto. Su participación en este plan es para coordinar las fechas del lanzamiento, requisitos de fabricación y requisitos de calidad para el producto completado.
- 31: La participación del departamento de ventas es para coordinar las fechas del lanzamiento, formar al equipo de ventas y cubrir los requisitos de personal.
- 33: En el plan de lanzamiento se incluye soporte de producto para garantizar que se comprenden las fechas del lanzamiento y que están preparados para dar soporte con un personal formado que puede satisfacer los objetivos de ventas.
- 35: La participación del servicio de campo es parecida al soporte de producto. Participan en el plan de lanzamiento para garantizar que se comprenden las fechas del lanzamiento y que están preparados para dar soporte con un personal formado que puede satisfacer los objetivos de ventas.
- 41: La receptividad del mercado se evalúa por los comentarios de los clientes claves, grupos de enfoque, mercados de prueba y pruebas beta.

| ID | WBS | Task | Type | Duration | Start | Finish | Predecessors | Total slack | Free slack | Resources | Work |
| --- | --- | --- | --- | --- | --- | --- | --- | --- | --- | --- | --- |
| 50 | 2.3.2 | **Ingeniería** |  | 1d? | 2015-12-10 | 2015-12-10 |  | 3d |  |  | 8h |
| 51 | 2.3.2.1 | Completar y probar producto |  | 1d? | 2015-12-10 | 2015-12-10 | 38 | 3d |  | Ingeniería | 8h |
| 52 | 2.3.3 | **Fabricación** |  | 1d? | 2015-12-10 | 2015-12-10 |  | 3d |  |  | 16h |
| 53 | 2.3.3.1 | Crear productos prototipo |  | 1d? | 2015-12-10 | 2015-12-10 | 38 | 3d |  | Fabricación | 8h |
| 54 | 2.3.3.2 | Preparar canalización |  | 1d? | 2015-12-10 | 2015-12-10 | 38 | 3d |  | Fabricación | 8h |
| 55 | 2.3.4 | **Ventas** |  | 1d? | 2015-12-10 | 2015-12-10 |  | 3d |  |  | 8h |
| 56 | 2.3.4.1 | Establecer canales de ventas |  | 1d? | 2015-12-10 | 2015-12-10 | 38 | 3d |  | Ventas | 8h |
| 57 | 2.3.5 | **Soporte técnico** |  | 1d? | 2015-12-10 | 2015-12-10 |  | 3d |  |  | 8h |
| 58 | 2.3.5.1 | Establecer mecanismos de soporte al producto |  | 1d? | 2015-12-10 | 2015-12-10 | 38 | 3d |  | Soporte técnico | 8h |
| 59 | 2.3.6 | **Servicio de campo** |  | 1d? | 2015-12-10 | 2015-12-10 |  | 3d |  |  | 8h |
| 60 | 2.3.6.1 | Establecer organizaciones del servicio de campo |  | 1d? | 2015-12-10 | 2015-12-10 | 38 | 3d |  | Servicio de campo | 8h |
| 61 | 2.3.7 | **Preparación para el lanzamiento a fabricación** |  | 2d? | 2015-12-10 | 2015-12-11 |  | 2d |  |  | 16h |
| 62 | 2.3.7.1 | Implementar control de cambio |  | 1d? | 2015-12-10 | 2015-12-10 | 38 | 2d | 0d | Director de producto | 8h |
| 63 | 2.3.7.2 | Finalizar directiva de soporte |  | 1d? | 2015-12-11 | 2015-12-11 | 62 | 2d |  | Director de producto | 8h |
| 64 | 2.3.8 | Fase de ejecución COMPLETADA | milestone | 0d | 2015-12-15 | 2015-12-15 | 63, 62, 60, 58, 56, 54, 53, 51, 49, 47 | 0d |  |  |  |
| 65 | 2.4 | **Fase 4: Lanzamiento a fabricación** |  | 3d? | 2015-12-16 | 2015-12-18 |  | 0d |  |  | 60h |
| 66 | 2.4.1 | **Fabricación** |  | 2d? | 2015-12-16 | 2015-12-17 |  | 0d |  |  | 24h |
| 67 | 2.4.1.1 | Certificar producto |  | 1d? | 2015-12-16 | 2015-12-16 | 64 | 0d |  | Fabricación; Director de producto | 16h |
| 68 | 2.4.1.2 | Fabricar el volumen planeado del producto para cumplir los objetivos de ventas. |  | 1d? | 2015-12-17 | 2015-12-17 | 67 | 0d |  | Fabricación | 8h |
| 69 | 2.4.2 | **Ventas** |  | 1d? | 2015-12-16 | 2015-12-16 |  | 1d |  |  | 8h |
| 70 | 2.4.2.1 | Contratar y formar al personal de ventas |  | 1d? | 2015-12-16 | 2015-12-16 | 64 | 1d |  | Ventas | 8h |
| 71 | 2.4.3 | **Soporte técnico** |  | 1d? | 2015-12-16 | 2015-12-16 |  | 1d |  |  | 8h |
| 72 | 2.4.3.1 | Contratar y formar al personal de soporte de productos |  | 1d? | 2015-12-16 | 2015-12-16 | 64 | 1d |  | Soporte técnico | 8h |
| 73 | 2.4.4 | **Servicio de campo** |  | 1d? | 2015-12-16 | 2015-12-16 |  | 1d |  |  | 8h |
| 74 | 2.4.4.1 | Contratar y formar al personal del servicio de campo |  | 1d? | 2015-12-16 | 2015-12-16 | 64 | 1d |  | Servicio de campo | 8h |

Notes:
- 51: Se evalúa el rendimiento del producto mediante la realización de pruebas y calificaciones.
- 53: Los procesos de producción se desarrollan usando líneas de producción piloto y más adelante usando líneas de producción reales.
- 54: La canalización de distribución tiene el nivel adecuado del producto.
- 62: Se completó y finalizó toda la documentación del producto y éste está bajo control de configuración. También se ha completado la documentación del usuario, manuales operativos e instrucciones de mantenimiento.
- 67: Se calificaron y validaron los procesos de producción y del producto y se obtuvieron todas las aprobaciones reglamentarias o certificaciones.

| ID | WBS | Task | Type | Duration | Start | Finish | Predecessors | Total slack | Resources | Work |
| --- | --- | --- | --- | --- | --- | --- | --- | --- | --- | --- |
| 75 | 2.4.5 | **Revisión de calidad final** |  | 1d? | 2015-12-18 | 2015-12-18 |  | 0d |  | 12h |
| 76 | 2.4.5.1 | Realizar revisión de calidad final |  | 1d? | 2015-12-18 | 2015-12-18 | 74, 72, 70, 68 | 0d | Ingeniería; Fabricación; Marketing; Ventas; Soporte técnico; Servicio de campo; Director de producto | 12h |
| 77 | 2.4.5.2 | Información de lanzamiento del producto COMPLETADA | milestone | 0d | 2015-12-18 | 2015-12-18 | 76 | 0d |  |  |
| 78 | 2.4.5.3 | Los materiales necesarios están pedidos o en existencias | milestone | 0d | 2015-12-18 | 2015-12-18 | 76 | 0d |  |  |
| 79 | 2.4.5.4 | Información COMPLETADA | milestone | 0d | 2015-12-18 | 2015-12-18 | 76 | 0d |  |  |
| 80 | 2.4.5.5 | Formación COMPLETADA | milestone | 0d | 2015-12-18 | 2015-12-18 | 76 | 0d |  |  |
| 81 | 2.4.6 | Lanzar producto | milestone | 0d | 2015-12-18 | 2015-12-18 | 80, 79, 78, 77, 76 | 0d |  |  |

Notes:
- 79: Se ha preparado la publicidad, folletos, materiales de marketing, comunicados de prensa y páginas Web y están listas para distribuirse en el momento adecuado.
- 80: Se ha formado al personal de soporte, servicio y ventas o se está desarrollando un programa de formación por fases.
- 81: El nuevo producto se lanza cuando los canales de distribución, ventas y servicio están listos.
